# Prototype nouveau modèle

Schedule from MS Project, 2018-01-08 to 2018-02-01, status date 2018-01-26, 7 hours a day, costs in €, A marks actual dates.

## Calendars

- Standard: Mon-Fri 09:00-12:00, 14:00-18:00; Sat-Sun off.

## Resources

| Resource | Rate |
| --- | --- |
| Gaston | 45 |
| Achille | 45 |

## Schedule

| ID | WBS | Task | Type | Duration | Start | Finish | Predecessors | Complete | Remaining | Baseline start | Baseline finish | Baseline duration | Baseline 1 start | Baseline 1 finish | Total slack | Free slack | Deadline | Resources | Work | Actual work | Cost | Baseline cost | Actual cost |
| --- | --- | --- | --- | --- | --- | --- | --- | --- | --- | --- | --- | --- | --- | --- | --- | --- | --- | --- | --- | --- | --- | --- | --- |
| 1 | 1 | Commande | milestone | 0d | 2018-01-08 A | 2018-01-08 A |  | 100% |  | 2018-01-08 | 2018-01-08 |  | 2018-01-08 | 2018-01-08 |  |  |  |  |  |  |  |  |  |
| 2 | 2 | **Etudes** |  | 7d | 2018-01-08 A | 2018-01-16 A |  | 100% |  | 2018-01-08 | 2018-01-15 | 6d | 2018-01-08 | 2018-01-16 |  |  |  |  | 49h | 49h | 2,205 | 1,890 | 2,205 |
| 3 | 2.1 | Analyse préalable |  | 3d | 2018-01-08 A | 2018-01-10 A | 1 | 100% |  | 2018-01-08 | 2018-01-09 | 2d | 2018-01-08 | 2018-01-10 |  |  |  | Gaston | 21h | 21h | 945 | 630 | 945 |
| 4 | 2.2 | Etudes électroniques |  | 2d | 2018-01-11 A | 2018-01-12 A | 3 | 100% |  | 2018-01-10 | 2018-01-11 | 2d | 2018-01-11 | 2018-01-12 |  |  |  | Achille | 14h | 14h | 630 | 630 | 630 |
| 5 | 2.3 | Etudes mécaniques |  | 2d | 2018-01-15 A | 2018-01-16 A | 4 | 100% |  | 2018-01-12 | 2018-01-15 | 2d | 2018-01-15 | 2018-01-16 |  |  |  | Gaston | 14h | 14h | 630 | 630 | 630 |
| 6 | 2.4 | Validation | milestone | 0d | 2018-01-16 A | 2018-01-16 A | 5 | 100% |  | 2018-01-15 | 2018-01-15 |  | 2018-01-16 | 2018-01-16 |  |  |  |  |  |  |  |  |  |
| 7 | 3 | **Fabrication** |  | 11d | 2018-01-18 A | 2018-02-01 |  | 50% | 5.5d | 2018-01-16 | 2018-01-25 | 8d | 2018-01-17 | 2018-01-26 | -2d | 0d |  |  | 98h | 42h | 4,410 | 3,780 | 1,890 |
| 8 | 3.1 | Fabrication électronique |  | 8d | 2018-01-18 A | 2018-01-30 | 6 | 75% | 2d | 2018-01-16 | 2018-01-23 | 6d | 2018-01-17 | 2018-01-24 | -2d | 0d |  | Achille | 56h | 42h | 2,520 | 1,890 | 1,890 |
| 9 | 3.2 | Fabrication mécanique |  | 2d | 2018-01-19 | 2018-01-22 | 8SS+1d |  |  | 2018-01-17 | 2018-01-18 | 2d | 2018-01-18 | 2018-01-19 | 4d |  |  | Gaston | 14h |  | 630 | 630 |  |
| 10 | 3.3 | Assemblage |  | 2d | 2018-01-31 | 2018-02-01 | 8, 9 |  |  | 2018-01-24 | 2018-01-25 | 2d | 2018-01-25 | 2018-01-26 | -2d | 0d |  | Achille; Gaston | 28h |  | 1,260 | 1,260 |  |
| 11 | 4 | PV de recette | milestone | 0d | 2018-02-01 | 2018-02-01 | 10 |  |  | 2018-01-25 | 2018-01-25 |  | 2018-01-26 | 2018-01-26 | -2d | 0d | 2018-01-30 |  |  |  |  |  |  |
